# modular PLASC

Schedule from MS Project, 2013-02-01 to 2014-05-02.
National Assembly for Wales

## Calendars

- Standard: Mon-Fri 08:00-12:00, 13:00-17:00; Sat-Sun off.

## Resources

| Resource |
| --- |
| AM |
| LL |
| MM |
| MP |
| JH |
| LO |
| CP |
| MS |
| SF |
| TG |
| GH |
| gWG |
| WG |
| Suppliers |
| M4/WG |
| Supplers |
| Suppliers/WG |

## Schedule

| ID | WBS | Task | Type | Duration | Start | Finish | Predecessors | Total slack | Free slack | Constraint | Deadline | Resources | Work |
| --- | --- | --- | --- | --- | --- | --- | --- | --- | --- | --- | --- | --- | --- |
| 2 | 1 | NDC 2013 Reporting Arrangements Released |  | 1d | 2013-04-09 | 2013-04-09 |  | 278d |  | start no earlier than 2013-04-09 |  | WG | 8h |
| 4 | 2 | Attendance Secondary 2013 Guidance Notes Released |  | 1d | 2013-04-25 | 2013-04-25 |  | 266d |  | start no earlier than 2013-04-25 |  | WG | 8h |
| 6 | 3 | **WED 2013 on DEWi** |  | 22d | 2013-04-16 | 2013-05-15 |  | 252d |  |  |  | M4/WG | 352h |
| 7 | 3.1 | WED 2013 DEWi development |  | 10d | 2013-04-16 | 2013-04-29 |  | 252d | 0d | start no earlier than 2013-04-16 |  | M4/WG | 80h |
| 8 | 3.2 | WED 2013 DEWi UAT |  | 5d | 2013-04-30 | 2013-05-06 | 7 | 252d | 0d | start no earlier than 2009-03-30 |  | M4/WG | 40h |
| 9 | 3.3 | WED 2013 DEWi rework |  | 3d | 2013-05-07 | 2013-05-09 | 8 | 252d | 0d | start no earlier than 2013-05-07 |  | M4/WG | 24h |
| 10 | 3.4 | WED 2013 Release to test DEWi site | milestone | 1d | 2013-05-10 | 2013-05-10 | 9 | 252d | 0d |  |  | M4/WG | 8h |
| 11 | 3.5 | WED 2013 DEWi UAT on test site |  | 2d | 2013-05-13 | 2013-05-14 | 10 | 252d | 0d |  |  | M4/WG | 16h |
| 12 | 3.6 | WED 2013 Release to live DEWi site | milestone | 1d | 2013-05-15 | 2013-05-15 | 11 | 252d |  | start no earlier than 2009-08-03 |  | M4/WG | 8h |
| 14 | 4 | Review and update the ULN collection, also taking account of CTF changes |  | 1d? | 2013-04-16 | 2013-04-16 |  | 273d |  | start no earlier than 2013-04-16 |  | WG | 8h |
| 17 | 5 | CTF13 draft release to suppliers |  | 1d | 2013-02-01 | 2013-02-01 |  | 325d |  | start no earlier than 2013-02-01 |  | WG | 8h |
| 19 | 6 | A_COMP 2013 Review |  | 43d | 2013-02-01 | 2013-04-02 |  | 283d |  | start no earlier than 2013-02-01 |  | WG | 344h |
| 20 | 7 | CTF13 final release to suppliers |  | 1d | 2013-03-01 | 2013-03-01 |  | 305d |  | start no earlier than 2013-03-01 |  | WG | 8h |
| 22 | 8 | **Spring SDF meetings** |  | 21d | 2013-02-15 | 2013-03-15 |  | -261d | 0d |  |  | Suppliers | 312h |
| 23 | 8.1 | Software Development Forum meeting | milestone | 1d | 2013-02-15 | 2013-02-15 |  | -261d | 0d | start no earlier than 2013-02-15 | 2012-02-16 | Suppliers/WG | 8h |
| 24 | 8.2 | Spec review period: PLASC, EOTAS & Attendance 2014 |  | 16d | 2013-02-18 | 2013-03-11 | 23 | 298d | 3d | finish no earlier than 2011-03-02 |  | Suppliers | 128h |
| 25 | 8.3 | Software Development Forum meeting | milestone | 1d | 2013-03-15 | 2013-03-15 | 24 | 295d |  | start no earlier than 2013-03-15 |  | Suppliers/WG | 8h |
| 28 | 9 | **CBDS (standard) change cycle** |  | 1d | 2013-04-02 | 2013-04-02 |  | 283d |  |  |  | WG | 40h |
| 29 | 9.1 | CBDS 1314 published - Pupil/School | milestone | 1d | 2013-04-02 | 2013-04-02 |  | 283d |  | start no earlier than 2013-04-02 |  | WG | 8h |
| 30 | 9.2 | A_COMP published |  | 1d | 2013-04-02 | 2013-04-02 |  | 283d |  | start no earlier than 2013-04-02 |  | WG | 8h |
| 31 | 9.3 | Publish 1314 Learning Activity codeset (look-up) | milestone | 1d | 2013-04-02 | 2013-04-02 |  | 283d |  | start no earlier than 2013-04-02 |  | WG | 8h |
| 32 | 9.4 | Publish 1314 Learning Activity Provider codeset (look-up) | milestone | 1d | 2013-04-02 | 2013-04-02 |  | 283d |  | start no earlier than 2013-04-02 |  | WG | 8h |
| 34 | 10 | **Develop January PLASC and EOTAS 2014** |  | 103d | 2013-02-08 | 2013-07-02 |  | 218d |  |  |  | WG | 1400h |
| 35 | 10.1 | **Specification** |  | 21d | 2013-02-08 | 2013-03-08 |  | 300d |  |  |  | WG | 312h |
| 36 | 10.1.1 | Draft specification release | milestone | 1d | 2013-02-08 | 2013-02-08 |  | 304d | 0d | start no earlier than 2013-02-08 |  | WG | 8h |
| 37 | 10.1.2 | Supplier review period |  | 16d | 2013-02-11 | 2013-03-04 | 36 | 304d |  |  |  | Suppliers | 128h |
| 38 | 10.1.3 | Version 1 specification release | milestone | 1d | 2013-03-08 | 2013-03-08 |  | 300d |  | start no earlier than 2013-03-08 |  | WG | 8h |

Notes:
- 24: Consider January PLASC 2011, Post-16 Summer PLASC 2011 and Attendance 2011 specifications
- 35: Publication in the same bundle as Post-16 Summer PLASC 2011 and Attendance Collections 2011

| ID | WBS | Task | Type | Duration | Start | Finish | Predecessors | Total slack | Free slack | Constraint | Resources | Work |
| --- | --- | --- | --- | --- | --- | --- | --- | --- | --- | --- | --- | --- |
| 39 | 10.2 | **xslt development** |  | 18d | 2013-06-04 | 2013-06-27 |  | 221d |  |  | WG | 248h |
| 40 | 10.2.1 | Draft fileset release | milestone | 1d | 2013-06-04 | 2013-06-04 |  | 226d | 0d | start no earlier than 2013-06-04 | WG | 8h |
| 41 | 10.2.2 | Supplier review period |  | 11d | 2013-06-05 | 2013-06-19 | 40 | 226d | 5d |  | Suppliers | 88h |
| 42 | 10.2.3 | Final fileset release | milestone | 1d | 2013-06-27 | 2013-06-27 | 41 | 221d |  | finish no earlier than 2013-06-27 | WG | 8h |
| 43 | 10.3 | **DEWi developments** |  | 1d | 2013-07-02 | 2013-07-02 |  | 218d |  |  | M4/WG | 16h |
| 44 | 10.3.1 | Release to supplier test DEWi sites for PLASC & EOTAS 2014 | milestone | 1d | 2013-07-02 | 2013-07-02 |  | 218d |  | start no earlier than 2013-07-02 | M4/WG | 8h |
| 45 | 11 | **January PLASC & EOTAS 2014 xslt and DEWi development** |  | 188d | 2013-04-16 | 2014-01-02 |  | 86d |  |  | M4/WG | 2056h |
| 46 | 11.1 | Jan & EOTAS 2014 xslt & DEWi development |  | 25d | 2013-04-16 | 2013-05-20 |  | 229d | 0d | start no earlier than 2013-04-16 | M4/WG | 200h |
| 47 | 11.2 | Jan & EOTAS 2014 xslt UAT |  | 9d | 2013-05-21 | 2013-05-31 | 46 | 229d | 0d | start no earlier than 2012-05-22 | M4/WG | 72h |
| 48 | 11.3 | Jan & EOTAS 2014 xslt draft fileset release | milestone | 1d | 2013-06-04 | 2013-06-04 | 47 | 238d |  | start no earlier than 2013-06-04 | M4/WG | 8h |
| 49 | 11.4 | Jan & EOTAS 2014 DEWi UAT |  | 8d | 2013-06-03 | 2013-06-12 | 47 | 229d | 8d | start no earlier than 2012-06-04 | M4/WG | 64h |
| 50 | 11.5 | Jan & EOTAS 2014 xslt supplier review period |  | 11d | 2013-06-05 | 2013-06-19 |  | 227d |  | start no earlier than 2013-06-05 | M4/WG | 88h |
| 51 | 11.6 | Jan & EOTAS 2014 xslt rework |  | 3d | 2013-06-20 | 2013-06-24 |  | 217d | 0d | start no earlier than 2013-06-20 | M4/WG | 24h |
| 52 | 11.7 | Jan & EOTAS 2014 xslt rework UAT |  | 2d | 2013-06-25 | 2013-06-26 | 51 | 217d | 0d | start no earlier than 2008-12-11 | M4/WG | 16h |
| 53 | 11.8 | Jan & EOTAS 2014 DEWi rework |  | 3d | 2013-06-25 | 2013-06-27 | 49, 51 | 221d |  | start no earlier than 2012-06-14 | M4/WG | 24h |
| 54 | 11.9 | Jan & EOTAS 2014 xslt final fileset release |  | 1d | 2013-06-27 | 2013-06-27 | 52 | 221d |  | start no earlier than 2012-06-27 | M4/WG | 8h |
| 55 | 11.10 | Jan & EOTAS 2014 Release to test DEWi site | milestone | 1d | 2013-06-27 | 2013-06-27 | 52 | 217d | 0d | start no earlier than 2012-06-27 | M4/WG | 8h |
| 56 | 11.11 | Jan & EOTAS 2014 DEWi UAT on test site |  | 3d | 2013-06-28 | 2013-07-02 | 55 | 217d | 0d | start no earlier than 2009-07-08 | M4/WG | 24h |
| 57 | 11.12 | Jan & EOTAS 2014 Release to supplier test DEWi site | milestone | 1d | 2013-07-03 | 2013-07-03 | 56 | 217d |  | start no earlier than 2009-07-14 | M4/WG | 8h |
| 58 | 11.13 | Jan & EOTAS 2014 Release to live DEWi site | milestone | 1d | 2014-01-02 | 2014-01-02 | 56 | 86d |  | start no earlier than 2014-01-02 | M4/WG | 8h |
| 61 | 12 | Post-16 PLASC 2013 Guidance Notes Released |  | 1d | 2013-08-23 | 2013-08-23 |  | 180d |  | start no earlier than 2013-08-23 | WG | 8h |
| 63 | 13 | Data removal - PLASC 2013 data | milestone | 1d | 2013-08-23 | 2013-08-23 |  | 180d |  | start no earlier than 2013-08-23 | WG | 8h |
| 65 | 14 | Fixed reports for NDC 2013 |  | 21d | 2013-08-27 | 2013-09-24 |  | 157d | 0d | start no earlier than 2013-08-27 | WG | 168h |
| 66 | 15 | Data removal - NDC 2013 data | milestone | 1d | 2013-09-25 | 2013-09-25 | 65 | 157d |  | start no earlier than 2009-09-30 | WG | 8h |
| 67 | 16 | Data removal - Attendance 2013 | milestone | 1d | 2013-10-25 | 2013-10-25 |  | 135d |  | start no earlier than 2013-10-25 | WG | 8h |

Notes:
- 53: Including released learning activity and provider codeset look-ups on 1/4/10

| ID | WBS | Task | Type | Duration | Start | Finish | Predecessors | Total slack | Free slack | Constraint | Resources | Work |
| --- | --- | --- | --- | --- | --- | --- | --- | --- | --- | --- | --- | --- |
| 69 | 17 | **Develop Attendance 2014** |  | 167d | 2013-02-08 | 2013-09-30 |  | 154d |  |  | WG | 1912h |
| 70 | 17.1 | **Specification** |  | 21d | 2013-02-08 | 2013-03-08 |  | 300d |  |  | WG | 312h |
| 71 | 17.1.1 | Draft specification release | milestone | 1d | 2013-02-08 | 2013-02-08 |  | 320d |  | start no earlier than 2013-02-08 | WG | 8h |
| 72 | 17.1.2 | Supplier review period |  | 16d | 2013-02-13 | 2013-03-06 |  | 302d |  | start no earlier than 2013-02-13 | Suppliers | 128h |
| 73 | 17.1.3 | Version 1 specification release | milestone | 1d | 2013-03-08 | 2013-03-08 |  | 300d |  | start no earlier than 2013-03-08 | WG | 8h |
| 74 | 17.2 | **xslt development** |  | 18d | 2013-09-03 | 2013-09-26 |  | 156d |  |  | WG | 248h |
| 75 | 17.2.1 | Draft fileset release | milestone | 1d | 2013-09-03 | 2013-09-03 |  | 161d | 0d | start no earlier than 2013-09-03 | WG | 8h |
| 76 | 17.2.2 | Supplier review period |  | 11d | 2013-09-04 | 2013-09-18 | 75 | 161d | 5d | start no earlier than 2010-09-07 | Suppliers | 88h |
| 77 | 17.2.3 | Final fileset release | milestone | 1d | 2013-09-26 | 2013-09-26 | 76 | 156d |  | start no earlier than 2013-09-26 | WG | 8h |
| 78 | 17.3 | **DEWi developments** |  | 1d | 2013-09-30 | 2013-09-30 |  | 154d |  |  | M4/WG | 16h |
| 79 | 17.3.1 | Release to supplier test DEWi sites for Attendance & NDC 2014 | milestone | 1d | 2013-09-30 | 2013-09-30 |  | 154d |  | finish no earlier than 2013-09-30 | M4/WG | 8h |
| 81 | 18 | Attendance Primary 2013 Guidance Notes Released |  | 1d | 2013-06-28 | 2013-06-28 |  | 220d |  | start no earlier than 2013-06-28 | WG | 8h |
| 83 | 19 | **Summer Attendance & NDC 2014 xslt and DEWi development** |  | 199d | 2013-07-30 | 2014-05-02 |  | 0d |  |  | M4/WG | 2072h |
| 84 | 19.1 | Summer 2014 xslt and DEWi development |  | 20d | 2013-07-30 | 2013-08-26 |  | 151d | 0d | start no earlier than 2013-07-30 | M4/WG | 160h |
| 85 | 19.2 | Summer 2014 xslt UAT |  | 5d | 2013-08-27 | 2013-09-02 | 84 | 151d | 0d | start no earlier than 2009-05-25 | M4/WG | 40h |
| 86 | 19.3 | Summer 2014 xslt draft fileset release | milestone | 1d | 2013-09-03 | 2013-09-03 | 85 | 151d | 0d | start no earlier than 2010-09-06 | M4/WG | 8h |
| 87 | 19.4 | Summer 2014 xslt supplier review period |  | 11d | 2013-09-04 | 2013-09-18 | 86 | 151d | 0d |  | M4/WG | 88h |
| 88 | 19.5 | Summer 2014 DEWi UAT |  | 5d | 2013-09-03 | 2013-09-09 | 85 | 163d | 7d |  | M4/WG | 40h |
| 89 | 19.6 | Summer 2014 xslt rework |  | 4d | 2013-09-19 | 2013-09-24 | 87 | 151d | 0d | finish no earlier than 2011-09-21 | M4/WG | 32h |
| 90 | 19.7 | Summer 2014 xslt rework UAT |  | 2d | 2013-09-25 | 2013-09-26 | 89 | 151d | 0d | start no earlier than 2008-12-11 | M4/WG | 16h |
| 91 | 19.8 | Summer 2014 DEWi rework |  | 5d | 2013-09-19 | 2013-09-25 | 87, 88 | 156d | 0d | start no earlier than 2012-09-13 | M4/WG | 40h |
| 92 | 19.9 | Summer 2014 Release to test DEWi site for NDC & Attendance collections 2013 |  | 1d | 2013-09-26 | 2013-09-26 | 91 | 156d |  | start no earlier than 2009-10-02 | M4/WG | 8h |
| 93 | 19.10 | Summer 2014 xslt final fileset release | milestone | 1d | 2013-09-27 | 2013-09-27 | 90 | 151d | 0d | start no earlier than 2012-09-26 | M4/WG | 8h |
| 94 | 19.11 | Summer 2014 DEWi UAT on test site |  | 3d | 2013-09-30 | 2013-10-02 | 93 | 151d | 0d |  | M4/WG | 24h |
| 95 | 19.12 | Summer 2014 Release to supplier test DEWi site for NDC & Attendance collections 2013 | milestone | 1d | 2013-10-03 | 2013-10-03 | 94 | 151d |  | start no earlier than 2011-10-03 | M4/WG | 8h |
| 96 | 19.13 | Summer 2014 Release to live DEWi site for NDC & Attendance collections 2013 | milestone | 1d | 2014-05-02 | 2014-05-02 | 94 | 0d |  | start no earlier than 2014-05-02 | M4/WG | 8h |

Notes:
- 70: Publication in the same bundle as January PLASC 2012
- 74: Development in the same bundle as NDC 2012
- 78: Development in the same bundle as NDC 2012
- 83: Summer Post-16 PLASC, Attendance and NDC 2012

| ID | WBS | Task | Type | Duration | Start | Finish | Predecessors | Total slack | Free slack | Constraint | Resources | Work |
| --- | --- | --- | --- | --- | --- | --- | --- | --- | --- | --- | --- | --- |
| 98 | 20 | **Summer SDF meeting** |  | 17d | 2013-06-07 | 2013-07-01 |  | 219d |  |  | Suppliers | 272h |
| 99 | 20.1 | Software Development Forum meeting | milestone | 1d | 2013-06-07 | 2013-06-07 |  | 219d | 0d | start no earlier than 2013-06-07 | Suppliers/WG | 8h |
| 100 | 20.2 | Spec review period |  | 16d | 2013-06-10 | 2013-07-01 | 99 | 219d |  | start no earlier than 2009-10-07 | Suppliers | 128h |
| 101 | 21 | **Develop NDC 2014** |  | 88d | 2013-05-31 | 2013-10-01 |  | 153d |  |  | WG | 1312h |
| 102 | 21.1 | **Specification** |  | 18d | 2013-05-31 | 2013-06-25 |  | 223d |  |  | WG | 288h |
| 103 | 21.1.1 | Draft specification release | milestone | 1d | 2013-05-31 | 2013-05-31 |  | 223d | 0d | start no earlier than 2013-05-31 | WG | 8h |
| 104 | 21.1.2 | Supplier review period |  | 16d | 2013-06-03 | 2013-06-24 | 103 | 223d | 0d | start no earlier than 2011-06-08 | Suppliers | 128h |
| 105 | 21.1.3 | Version 1 specification release | milestone | 1d | 2013-06-25 | 2013-06-25 | 104 | 223d |  | start no earlier than 2012-06-27 | WG | 8h |
| 106 | 21.2 | **xslt development** |  | 19d | 2013-09-03 | 2013-09-27 |  | 155d |  |  | WG | 304h |
| 107 | 21.2.1 | Draft fileset release | milestone | 1d | 2013-09-03 | 2013-09-03 |  | 155d | 0d | start no earlier than 2013-09-03 | WG | 8h |
| 108 | 21.2.2 | Supplier review period |  | 11d | 2013-09-04 | 2013-09-18 | 107 | 161d | 0d | start no earlier than 2008-09-16 | Suppliers | 88h |
| 109 | 21.2.3 | Final fileset release | milestone | 7d | 2013-09-19 | 2013-09-27 | 108 | 155d |  | finish no earlier than 2013-09-27 | WG | 56h |
| 110 | 21.3 | **DEWi developments** |  | 1d | 2013-10-01 | 2013-10-01 |  | 153d |  |  | M4/WG | 16h |
| 111 | 21.3.1 | Release to supplier test DEWi sites for Attendance & NDC 2014 | milestone | 1d | 2013-10-01 | 2013-10-01 |  | 153d |  | start no earlier than 2013-10-01 | M4/WG | 8h |
| 113 | 22 | DEWI user audit |  | 20d | 2013-09-03 | 2013-09-30 |  | 154d |  | start no earlier than 2013-09-03 | WG | 160h |
| 115 | 23 | s2s user audit |  | 20d | 2013-09-03 | 2013-09-30 |  | 154d |  | start no earlier than 2013-09-03 | WG | 160h |
| 118 | 24 | **Autumn SDF meetings** |  | 21d | 2013-10-09 | 2013-11-06 |  | 127d |  |  | Suppliers | 312h |
| 119 | 24.1 | Software Development Forum meeting | milestone | 1d | 2013-10-09 | 2013-10-09 |  | 130d | 0d | start no earlier than 2013-10-09 | Suppliers/WG | 8h |
| 120 | 24.2 | Spec review period |  | 16d | 2013-10-10 | 2013-10-31 | 119 | 130d | 3d | start no earlier than 2009-10-07 | Suppliers | 128h |
| 121 | 24.3 | Software Development Forum meeting | milestone | 1d | 2013-11-06 | 2013-11-06 | 120 | 127d |  | start no earlier than 2013-11-06 | Suppliers/WG | 8h |
| 124 | 25 | **Develop Post-16 September PLASC 2014** |  | 136d | 2013-10-04 | 2014-04-11 |  | 15d |  |  | WG | 3000h |
| 125 | 25.1 | **Specification** |  | 21d | 2013-10-04 | 2013-11-01 |  | 130d |  |  | WG | 312h |
| 126 | 25.1.1 | Draft specification release | milestone | 1d | 2013-10-04 | 2013-10-04 |  | 134d | 0d | start no earlier than 2013-10-04 | WG | 8h |
| 127 | 25.1.2 | Supplier review period |  | 16d | 2013-10-07 | 2013-10-28 | 126 | 134d |  | start no earlier than 2011-10-12 | Suppliers | 128h |
| 128 | 25.1.3 | Version 1 specification release | milestone | 1d | 2013-11-01 | 2013-11-01 |  | 130d |  | start no earlier than 2013-11-01 | WG | 8h |

Notes:
- 100: Consider Post-16 September PLASC 2012 specification
- 106: Development in the same bundle as Post-16 Summer PLASC 2010 and Attendance Collections 2010
- 110: Development in the same bundle as Post-16 Summer PLASC 2010 and Attendance Collections 2010
- 120: Consider Post-16 September PLASC 2010 specification

| ID | WBS | Task | Type | Duration | Start | Finish | Predecessors | Total slack | Free slack | Constraint | Resources | Work |
| --- | --- | --- | --- | --- | --- | --- | --- | --- | --- | --- | --- | --- |
| 129 | 25.2 | **xslt development** |  | 103d | 2013-11-20 | 2014-04-11 |  | 15d |  |  | WG | 936h |
| 130 | 25.2.1 | Draft fileset release | milestone | 1d | 2013-11-20 | 2013-11-20 |  | 105d | 0d | start no earlier than 2013-11-20 | WG | 8h |
| 131 | 25.2.2 | Supplier review period |  | 11d | 2013-11-21 | 2013-12-05 | 130 | 105d | 0d |  | Suppliers | 88h |
| 132 | 25.2.3 | Final fileset release | milestone | 1d | 2013-12-13 | 2013-12-13 | 131 | 100d |  | start no earlier than 2013-12-13 | WG | 8h |
| 133 | 25.2.4 | Update of fileset release with 14/15 look-ups |  | 1d | 2014-04-11 | 2014-04-11 |  | 15d |  | start no earlier than 2014-04-11 | WG | 8h |
| 134 | 25.3 | **DEWi developments** |  | 81d | 2013-12-13 | 2014-04-04 |  | 20d |  |  | M4/WG | 664h |
| 135 | 25.3.1 | Release to supplier test DEWi sites for Post-16 September PLASC 2014 | milestone | 1d | 2013-12-13 | 2013-12-13 |  | 100d |  | start no earlier than 2013-12-13 | M4/WG | 8h |
| 136 | 25.3.2 | Release update with look-ups to supplier test DEWi site Post-16 September PLASC 2014 |  | 1d | 2014-04-04 | 2014-04-04 |  | 20d |  | start no earlier than 2014-04-04 | M4/WG | 8h |
| 138 | 26 | **Post-16 Sept 2014 xslt and DEWi development** |  | 115d | 2013-11-01 | 2014-04-10 |  | 16d |  |  | M4/WG | 1344h |
| 139 | 26.1 | Sept 2014 xslt and DEWi development |  | 10d | 2013-11-01 | 2013-11-14 |  | 92d | 0d | start no earlier than 2013-11-01 | M4/WG | 80h |
| 140 | 26.2 | Sept 2014 xslt UAT |  | 3d | 2013-11-15 | 2013-11-19 | 139 | 92d | 0d | start no earlier than 2009-11-16 | M4/WG | 24h |
| 141 | 26.3 | Sept 2014 xslt draft fileset release | milestone | 1d | 2013-11-20 | 2013-11-20 | 140 | 92d | 0d | start no earlier than 2009-11-23 | M4/WG | 8h |
| 142 | 26.4 | Sept 2014 xslt supplier review period |  | 11d | 2013-11-21 | 2013-12-05 | 141 | 92d | 0d |  | M4/WG | 88h |
| 143 | 26.5 | September 2014 DEWi UAT |  | 3d | 2013-11-20 | 2013-11-22 | 140 | 105d | 9d |  | M4/WG | 24h |
| 144 | 26.6 | Sept 2014 xslt rework |  | 3d | 2013-12-06 | 2013-12-10 | 142 | 92d | 0d |  | M4/WG | 24h |
| 145 | 26.7 | Sept 2014 xslt rework UAT |  | 2d | 2013-12-11 | 2013-12-12 | 144 | 92d | 0d |  | M4/WG | 16h |
| 146 | 26.8 | September 2014 DEWi rework |  | 5d | 2013-12-06 | 2013-12-12 | 142, 143 | 96d | 0d |  | M4/WG | 40h |
| 147 | 26.9 | September 2014 Release to test DEWi site |  | 1d | 2013-12-13 | 2013-12-13 | 146 | 96d | 0d |  | M4/WG | 8h |
| 148 | 26.10 | Sept 2014 xslt final fileset release | milestone | 1d | 2013-12-13 | 2013-12-13 | 145 | 92d | 76d | start no earlier than 2011-12-12 | M4/WG | 8h |
| 149 | 26.11 | September 2014 DEWi UAT on test site |  | 3d | 2013-12-16 | 2013-12-18 | 147 | 96d | 0d |  | M4/WG | 24h |
| 150 | 26.12 | September 2014 Release to supplier test DEWi site | milestone | 1d | 2013-12-19 | 2013-12-19 | 149 | 96d |  | start no earlier than 2013-12-19 | M4/WG | 8h |
| 151 | 26.13 | Sept 2014 xslt and DEWi inclusion of 14/15 look-ups |  | 4d | 2014-04-01 | 2014-04-04 | 148 | 16d | 0d | start no earlier than 2014-04-01 | M4/WG | 32h |
| 152 | 26.14 | Sept 2014 xslt and DEWi UAT on 14/15 look-ups update |  | 3d | 2014-04-07 | 2014-04-09 | 151 | 16d | 0d |  | M4/WG | 24h |
| 153 | 26.15 | Sept 2014 xslt update release | milestone | 1d | 2014-04-10 | 2014-04-10 | 152 | 16d |  | start no earlier than 2010-04-15 | M4/WG | 8h |
| 154 | 26.16 | September 2014 Release to live DEWi site | milestone | 1d | 2014-04-10 | 2014-04-10 | 152 | 16d |  | start no earlier than 2010-09-16 | M4/WG | 8h |
| 156 | 27 | CTF14 consultation |  | 21d | 2013-12-03 | 2013-12-31 |  | 88d |  | start no earlier than 2013-12-03 | WG | 168h |
| 158 | 28 | Jan PLASC & EOTAS 2014 Guidance Notes Released |  | 1d | 2013-12-10 | 2013-12-10 |  | 103d |  | start no earlier than 2013-12-10 | WG | 8h |
| 160 | 29 | Data Demons Released |  | 1d | 2013-12-10 | 2013-12-10 |  | 103d |  | start no earlier than 2013-12-10 | WG | 8h |
| 162 | 30 | Data removal - Post-16 September PLASC 2013 data | milestone | 1d | 2014-01-24 | 2014-01-24 |  | 70d |  | start no earlier than 2014-01-24 | WG | 8h |
| 164 | 31 | CTF14 draft release to suppliers |  | 20d | 2014-01-31 | 2014-02-27 |  | 46d |  | start no earlier than 2014-01-31 | WG | 160h |
